# CRONOGRAMA PROYECTO N°02

Schedule from MS Project, 2018-10-01 to 2018-11-30, status date 2018-11-18, costs in S.
Microsoft

## Calendars

- Estándar: Mon-Sun 08:00-13:00, 14:00-17:00.

## Schedule

| ID | WBS | Task | Type | Duration | Start | Finish | Predecessors | Total slack | Free slack | Cost | Text1 |
| --- | --- | --- | --- | --- | --- | --- | --- | --- | --- | --- | --- |
| 1 | 1 | **"REPARACIÓN DE VIAS DEPARTAMENTALES; EN EL(LA) CAMINO DEPARTAMENTAL TU 104 EN 6.904 KM EN EMP. PE 1 N (TUMBES) - SAN JUAN DE LA VIRGEN- PAMPAS HOSPITAL-CABUYAL - EL PRADO - CAÑON EL TIGRE, TRAMO SALIDA DEL C.P EL LIMON -CAÑON EL TIGRE DISTRITO DE PAMPAS.** |  | 60d | 2018-10-01 | 2018-11-30 |  | 0d |  | 1,021,248.99 |  |
| 2 | 1.1 | INICIO DEL PROYECTO | milestone | 0d | 2018-10-01 | 2018-10-01 |  | 0d |  |  |  |
| 3 | 1.2 | **REPARACION DE VIAS** |  | 60d | 2018-10-01 | 2018-11-30 |  | 0d |  | 1,021,248.99 | 01 |
| 4 | 1.2.1 | **OBRAS PROVISIONALES** |  | 60d | 2018-10-01 | 2018-11-30 |  | 0d |  | 97,443.1 | 01.01 |
| 5 | 1.2.1.1 | SUMINISTRO Y COLOCACION DE CARTEL DE OBRA (5.60x3.40m) |  | 1d | 2018-10-01 | 2018-10-02 | 2 | 29d | 0d | 1,074.18 | 01.01.01 |
| 6 | 1.2.1.2 | CASETA PARA OFICINA, ALMACEN Y GUARDIANIA |  | 2d | 2018-10-02 | 2018-10-04 | 5 | 29d | 0d | 3,364 | 01.01.02 |
| 7 | 1.2.1.3 | MOVILIZACION Y DESMOVILIZACION DE EQUIPOS |  | 30d | 2018-10-02 | 2018-11-01 | 6SS | 29d |  | 24,650 | 01.01.03 |
| 8 | 1.2.1.4 | MANTENIMIENTO DEL TRANSITO Y SEGURIDAD VIAL |  | 60d | 2018-10-01 | 2018-11-30 | 2SS | 0d |  | 4,716.12 | 01.01.04 |
| 9 | 1.2.1.5 | PLAN DE MONITOREO DE IMPACTO AMBIENTAL |  | 50d | 2018-10-01 | 2018-11-20 | 2SS | 0d |  | 36,240 | 01.01.05 |
| 10 | 1.2.1.6 | PLAN DE MONITOREO ARQUEOLOGICO |  | 50d | 2018-10-01 | 2018-11-20 | 9SS | 0d |  | 8,003.8 | 01.01.06 |
| 11 | 1.2.1.7 | ELABORACION, IMPLEMENTACION Y ADMINISTRACION DEL PLAN DE SEGURIDAD Y SALUD EN EL TRABAJO |  | 60d | 2018-10-01 | 2018-11-30 | 10SS | 0d |  | 19,395 | 01.01.07 |
| 12 | 1.2.2 | **TRABAJOS PRELIMINARES** |  | 12d | 2018-10-01 | 2018-10-13 |  | 0d |  | 81,220.71 | 01.02 |
| 13 | 1.2.2.1 | TRAZO, NIVELACION Y REPLANTEO |  | 5d | 2018-10-07 | 2018-10-12 | 14FS-4d | 0d |  | 28,996.8 | 01.02.01 |
| 14 | 1.2.2.2 | DESBROCE Y LIMPIEZA DE MALEZA |  | 10d | 2018-10-01 | 2018-10-11 | 2SS | 0d |  | 24,854.4 | 01.02.02 |
| 15 | 1.2.2.3 | ELIMINACIÓN DE MATERIAL EXCEDENTE PROCEDENTE DE DESBROCE |  | 2d | 2018-10-11 | 2018-10-13 | 14 | 48d |  | 27,369.51 | 01.02.03 |
| 16 | 1.2.3 | **EXCAVACIONES** |  | 26d | 2018-10-08 | 2018-11-03 |  | 0d |  | 565,438.43 | 01.03 |
| 17 | 1.2.3.1 | CORTE DE TERRENO NATURAL CON MAQUINARIA |  | 15d | 2018-10-08 | 2018-10-23 | 13SS+1d | 0d |  | 46,127.89 | 01.03.01 |
| 18 | 1.2.3.2 | RELLENO CON MATERIAL PROPIO CON EQUIPO |  | 8d | 2018-10-26 | 2018-11-03 | 20FS-7d | 0d |  | 48,869.27 | 01.03.02 |
| 19 | 1.2.3.3 | PERFILADO Y COMPACTACION DE SUBRASANTE PARA CONFORMACION DE VIA |  | 11d | 2018-10-16 | 2018-10-27 | 17FS-7d | 0d |  | 109,083.2 | 01.03.03 |
| 20 | 1.2.3.4 | BASE GRANULAR MATERIAL SELECCIONADO (AFIRMADO) E=0.20 M |  | 15d | 2018-10-18 | 2018-11-02 | 19SS+2d | 0d |  | 328,906.56 | 01.03.04 |
| 21 | 1.2.3.5 | ELIMINACIÓN DE MATERIAL EXCEDENTE D. PROM 2.5 KM DE LA OBRA |  | 2d | 2018-10-23 | 2018-10-25 | 17 | 36d |  | 32,451.51 | 01.03.05 |
| 22 | 1.2.4 | **IMPRIMACION ASFALTICA** |  | 17d | 2018-11-03 | 2018-11-20 |  | 0d |  | 249,924.8 | 01.04 |
| 23 | 1.2.4.1 | BARRIDO DE VIA ANTES DE RIEGO DE LIGA |  | 7d | 2018-11-03 | 2018-11-10 | 18 | 0d |  | 15,741.12 | 01.04.01 |
| 24 | 1.2.4.2 | IMPRIMACION ASFALTICA REFORZADA CON MC-30 |  | 10d | 2018-11-10 | 2018-11-20 | 23 | 0d |  | 234,183.68 | 01.04.02 |

| ID | WBS | Task | Type | Duration | Start | Finish | Predecessors | Total slack | Cost | Text1 |
| --- | --- | --- | --- | --- | --- | --- | --- | --- | --- | --- |
| 25 | 1.2.5 | **ENROCADO** |  | 10d | 2018-11-20 | 2018-11-30 |  | 0d | 27,221.95 | 01.05 |
| 26 | 1.2.5.1 | ENROCADO E=0.20 m. EMBEBIDO EN CONCRETO PROP. 1:8 + 60% P.G. 06" |  | 6d | 2018-11-22 | 2018-11-28 | 27 | 0d | 23,936.4 | 01.05.01 |
| 27 | 1.2.5.2 | ENCOFRADO Y DESENCOFRADO DE ENROCADO |  | 2d | 2018-11-20 | 2018-11-22 | 24 | 0d | 1,141.92 | 01.05.02 |
| 28 | 1.2.5.3 | UÑA ENROCADO C:H, 1:8 + 30% PM |  | 6d | 2018-11-22 | 2018-11-28 | 26SS | 0d | 1,678.03 | 01.05.03 |
| 29 | 1.2.5.4 | JUNTA ASFALTICA E=1" |  | 2d | 2018-11-28 | 2018-11-30 | 28 | 0d | 465.6 | 01.05.04 |
| 30 | 1.3 | FIN DEL PROYECTO | milestone | 0d | 2018-11-30 | 2018-11-30 | 29 | 0d |  |  |
